# Professional_WBS_120_Activities

How a schedule from MS Project changed from version to version. A marks actual dates.

## Version 1 (saved 2026-07-13, file actual.mpp)

| ID | WBS | Task | Duration | Start | Finish | Predecessors | Complete | Total float |
| --- | --- | --- | --- | --- | --- | --- | --- | --- |
| 1 | 1 | **پروژه احداث نیروگاه گازسوز 2000 کیلووات (CAT CG170)** | 193d | 2026-01-03 A | 2026-08-15 |  | 67% | 0d |
| 2 |  | شروع | 0d | 2026-01-03 A | 2026-01-03 A |  | 100% |  |
| 3 | 1.2 | **تشریفات قرارداد (contract)** | 122d | 2026-01-03 A | 2026-05-24 A |  | 100% |  |
| 4 |  | تهیه اسناد مناقصه و برگزاری تشریفات مناقصه | 60d | 2026-01-03 A | 2026-03-12 A | 2 | 100% |  |
| 5 |  | مذاکرات قراردادی و انعقاد قرارداد با پیمانکار EPC | 26d | 2026-03-14 A | 2026-04-12 A | 4 | 100% |  |
| 6 |  | انعقاد قرارداد MC | 1d | 2026-05-24 A | 2026-05-24 A | 5FS+35d | 100% |  |
| 7 | 1.1 | **مهندسی و طراحی (Engineering)** | 43.4d | 2026-04-14 A | 2026-06-03 |  | 94% | 62.6d |
| 8 | 1.1.1 | **طراحی پایه (Basic Design)** | 43.4d | 2026-04-14 A | 2026-06-03 |  | 95% | 62.6d |
| 9 |  | تهیه نقشه های جانمایی (General Layout) | 5d | 2026-04-14 A | 2026-05-26 | 6 | 95% | 0.15d |
| 10 |  | تهیه نمودارهای P&ID سیستم های مکانیک | 5d | 2026-04-18 A | 2026-05-27 | 9 | 95% | 2.3d |
| 11 | 1.1.1.3 | **طراحی تک خطی دیاگرام های برقی (SLD)** | 36.4d | 2026-04-22 A | 2026-06-03 |  | 95% | 62.6d |
| 12 |  | آماده سازی برای طراحی تک خطی دیاگرام های برقی (SLD) | 6d | 2026-04-22 A | 2026-05-31 | 10 | 95% | 2.5d |
| 13 |  | اجرای نهایی و بازرسی طراحی تک خطی دیاگرام های برقی (SLD) | 6d | 2026-04-26 A | 2026-06-03 | 12 | 95% | 62.6d |
| 14 | 1.1.2 | **مهندسی تفصیلی (Detail Design)** | 36.9d | 2026-04-18 A | 2026-05-30 |  | 94% | 66.1d |
| 15 | 1.3.2.1 | **مهندسی عمران و سازه** | 35.4d | 2026-04-18 A | 2026-05-28 |  | 97% | 67.6d |
| 16 | 1.3.2.1.1 | **طراحی عمومی سایت** | 34.2d | 2026-04-18 A | 2026-05-27 |  | 95% | 0.05d |
| 17 |  | پلان کلی سایت (Plot Plan) | 1d | 2026-04-18 A | 2026-05-27 | 9 | 95% | 0.05d |
| 18 | 1.3.2.1.2 | **طراحی فونداسیون‌ها** | 2d | 2026-04-19 A | 2026-04-20 |  | 99% | 100d |
| 19 |  | فونداسیون موتور | 1d | 2026-04-19 A | 2026-04-19 A | 17 | 100% |  |
| 20 |  | فونداسیون ترانسفورماتور | 1d | 2026-04-20 A | 2026-04-20 A | 19 | 100% |  |
| 21 |  | فونداسیون مخازن آب و روغن | 1d | 2026-04-20 A | 2026-04-20 A | 19 | 100% |  |
| 22 |  | فونداسیون ایرکولر | 1d | 2026-04-20 A | 2026-04-20 | 19 | 95% | 100d |
| 23 |  | فونداسیون پمپ‌ها | 1d | 2026-04-20 A | 2026-04-20 A | 19 | 100% |  |
| 24 | 1.3.2.1.3 | **سیستم‌های زیرزمینی** | 33.4d | 2026-04-20 A | 2026-05-28 |  | 94% | 67.6d |
| 25 |  | طراحی کانال کابل | 1d | 2026-04-20 A | 2026-05-27 | 17 | 95% | 0.15d |
| 26 |  | طراحی ترانشه لوله | 1d | 2026-04-21 A | 2026-05-27 | 25 | 95% | 0.15d |
| 27 |  | طراحی پایپ اسلیپر | 1d | 2026-04-22 A | 2026-05-27 | 26 | 95% | 68.2d |
| 28 |  | طراحی چاه‌های ارت | 1d | 2026-05-27 A | 2026-05-28 | 25 | 90% | 0.95d |
| 29 | 1.3.2.1.4 | **ساختمان‌ها و معماری** | 32.5d | 2026-04-20 A | 2026-05-27 |  | 95% | 68.5d |
| 30 |  | معماری سالن موتور | 1d | 2026-04-20 A | 2026-05-27 | 17 | 95% | 0.15d |
| 31 |  | معماری شلتر (نما، مقطع، جزئیات) | 1d | 2026-04-21 A | 2026-05-27 | 30 | 95% | 68.5d |
| 32 |  | ساختمان CCB / اتاق کنترل / سوئیچگی | 1d | 2026-04-21 A | 2026-05-27 | 30 | 95% | 0d |
| 33 | 1.3.2.1.5 | **جزئیات سازه‌ای** | 3d | 2026-04-21 A | 2026-04-23 |  | 98% | 97d |
| 34 |  | نقشه سازه‌ای دودکش (Stack) | 1d | 2026-04-21 A | 2026-04-21 A | 30 | 100% |  |
| 35 |  | سکوی رادیاتور | 2d | 2026-04-21 A | 2026-04-22 A | 22 | 100% |  |
| 36 |  | سازه های نصب تجهیزات مکانیکی | 3d | 2026-04-21 A | 2026-04-23 | 23 | 95% | 97d |
| 37 | 1.3.2.2 | **مهندسی مکانیک** | 30.7d | 2026-04-22 A | 2026-05-27 |  | 94% | 68.3d |
| 38 | 1.3.2.2.1 | **مبانی طراحی مکانیک** | 4d | 2026-04-22 A | 2026-04-26 A |  | 100% |  |
| 39 |  | شرح فرآیند | 2d | 2026-04-22 A | 2026-04-23 A | 10 | 100% |  |
| 40 |  | معیارهای طراحی مکانیک | 2d | 2026-04-25 A | 2026-04-26 A | 39 | 100% |  |
| 41 | 1.3.2.2.2 | **تجهیزات دوار** | 5d | 2026-04-27 A | 2026-05-02 |  | 90% | 90d |
| 42 |  | مشخصات و دیتاشیت موتورهای گازسوز | 1d | 2026-04-27 A | 2026-04-27 A | 40 | 100% |  |
| 43 | 1.3.2.2.2.2 | **مهندسی و خرید پمپ‌ها** | 4d | 2026-04-28 A | 2026-05-02 |  | 88% | 90d |
| 44 |  | تهیه دیتاشیت پمپ LT Oil Feed | 1d | 2026-04-28 A | 2026-04-28 A | 42 | 100% |  |
| 45 |  | تهیه دیتاشیت پمپ HT Oil Feed | 1d | 2026-04-29 A | 2026-04-29 A | 44 | 100% |  |
| 46 |  | تهیه دیتاشیت پمپ Feed Water | 1d | 2026-04-30 A | 2026-04-30 A | 45 | 100% |  |
| 47 |  | تهیه دیتاشیت سایر پمپ‌ها (Utility / Service / Cooling) | 1d | 2026-05-02 A | 2026-05-02 | 46 | 50% | 90d |
| 48 | 1.3.2.2.3 | **تجهیزات ثابت** | 26.7d | 2026-04-27 A | 2026-05-27 |  | 98% | 68.3d |
| 49 |  | مشخصات مخازن | 1d | 2026-04-27 A | 2026-04-27 A | 40 | 100% |  |
| 50 |  | سیستم تهویه و فن‌ها | 1d | 2026-04-27 A | 2026-05-27 | 30, 40 | 95% | 68.3d |
| 51 | 1.3.2.2.4 | **مهندسی پایپینگ** | 4d | 2026-04-28 A | 2026-05-02 |  | 91% | 90d |
| 52 |  | نقشه‌های آرایش لوله (GA) | 1d | 2026-04-28 A | 2026-04-28 | 42 | 90% | 0.8d |
| 53 |  | نقشه‌های ایزومتریک | 1d | 2026-04-29 A | 2026-04-29 | 52 | 80% | 0.95d |
| 54 |  | نقشه‌های ساپورت لوله | 1d | 2026-04-30 A | 2026-04-30 | 53 | 95% | 91d |
| 55 |  | متره و برآورد لوله‌ها (MTO) | 1d | 2026-04-30 A | 2026-04-30 | 53 | 95% | 0.95d |
| 56 |  | عایق‌کاری و پوشش | 1d | 2026-05-02 A | 2026-05-02 | 55 | 95% | 90d |
| 57 | 1.3.2.2.5 | **سیستم‌های جانبی** | 2d | 2026-04-29 A | 2026-04-30 |  | 95% | 91d |
| 58 |  | سیستم خنک‌کاری | 1d | 2026-04-29 A | 2026-04-29 | 42, 52 | 95% | 0.95d |
| 59 |  | سیستم روغن‌کاری | 1d | 2026-04-30 A | 2026-04-30 | 58 | 95% | 91d |
| 60 |  | سیستم اگزاست | 1d | 2026-04-30 A | 2026-04-30 | 58 | 95% | 91d |
| 61 |  | سیستم هوای سالن | 1d | 2026-04-30 A | 2026-04-30 | 58 | 95% | 91d |
| 62 | 1.3.2.2.6 | **مهندسی فرآیند** | 4d | 2026-04-26 A | 2026-04-29 |  | 93% | 0.8d |
| 63 | 1.3.2.2.6.1 | **طراحی فرآیند** | 4d | 2026-04-26 A | 2026-04-29 |  | 93% | 0.8d |
| 64 |  | تهیه PFD | 1d | 2026-04-26 A | 2026-04-26 A |  | 100% |  |
| 65 |  | تهیه P&ID | 1d | 2026-04-27 A | 2026-04-27 | 64 | 90% | 0.8d |
| 66 |  | محاسبات هیدرولیکی | 1d | 2026-04-28 A | 2026-04-28 | 65 | 90% | 0.9d |
| 67 |  | سایزینگ خطوط | 1d | 2026-04-29 A | 2026-04-29 | 66 | 90% | 0.8d |
| 68 | 1.3.2.2.7 | **دیتاشیت‌ و اسپک** | 1d | 2026-04-30 A | 2026-04-30 |  | 98% | 91d |
| 69 |  | پمپ‌ها | 1d | 2026-04-30 A | 2026-04-30 A | 67 | 100% |  |
| 70 |  | مولد | 1d | 2026-04-30 A | 2026-04-30 A | 67 | 100% |  |

| ID | WBS | Task | Duration | Start | Finish | Predecessors | Complete | Total float |
| --- | --- | --- | --- | --- | --- | --- | --- | --- |
| 71 |  | سیستم خنک کاری (مولد و سالن) | 1d | 2026-04-30 A | 2026-04-30 | 67 | 95% | 91d |
| 72 | 1.3.2.2.8 | **مستندات بهره‌برداری** | 1d | 2026-04-28 A | 2026-04-28 |  | 96% | 93d |
| 73 |  | دستورالعمل بهره‌برداری | 1d | 2026-04-28 A | 2026-04-28 | 65 | 96% | 93d |
| 74 | 1.3.2.3 | **مهندسی برق** | 32.9d | 2026-04-22 A | 2026-05-30 |  | 95% | 66.1d |
| 75 | 1.3.2.3.1 | **سیستم قدرت** | 3.5d | 2026-05-03 A | 2026-05-06 |  | 95% | 86.5d |
| 76 |  | دیتا شیت و اسپک ترانسفورماتور قدرت | 2d | 2026-05-03 A | 2026-05-04 |  | 95% | 0.45d |
| 77 |  | دیتا شیت و اسپک سوئیچگیر MV | 2d | 2026-05-04 A | 2026-05-06 | 76 | 95% | 0.15d |
| 78 |  | AUX دیتا شیت و اسپک | 1d | 2026-05-04 A | 2026-05-05 | 76 | 95% | 0.45d |
| 79 |  | تابلوهای توزیع LV دیتا شیت و اسپک | 1d | 2026-05-05 A | 2026-05-05 | 78 | 95% | 87d |
| 80 | 1.3.2.3.2 | **مطالعات سیستم قدرت** | 4d | 2026-05-05 A | 2026-05-09 |  | 90% | 84d |
| 81 |  | مطالعات اتصال کوتاه | 2d | 2026-05-05 A | 2026-05-06 | 76 | 90% | 0.9d |
| 82 |  | مطالعات پخش بار | 1d | 2026-05-07 A | 2026-05-07 | 81 | 90% | 0.9d |
| 83 |  | مطالعات اتصال به شبکه | 1d | 2026-05-09 A | 2026-05-09 | 81, 82 | 90% | 84d |
| 84 | 1.3.2.3.3 | **کابل‌کشی** | 4d | 2026-05-03 A | 2026-05-06 |  | 98% | 86d |
| 85 |  | محاسبات سایز کابل | 1d | 2026-05-03 A | 2026-05-03 A |  | 100% |  |
| 86 |  | لیست کابل‌ها | 1d | 2026-05-04 A | 2026-05-04 A | 85 | 100% |  |
| 87 |  | طراحی سینی کابل | 1d | 2026-05-05 A | 2026-05-05 | 86 | 95% | 0.95d |
| 88 |  | کابل‌ها (MTO) و سینی ها | 1d | 2026-05-06 A | 2026-05-06 | 86, 87 | 95% | 86d |
| 89 | 1.3.2.3.4 | **ارت و روشنایی** | 32.4d | 2026-04-22 A | 2026-05-30 |  | 98% | 66.6d |
| 90 |  | طراحی سیستم ارتینگ | 1d | 2026-05-28 A | 2026-05-30 | 25, 28 | 95% | 66.6d |
| 91 |  | طراحی روشنایی | 1d | 2026-04-22 A | 2026-04-22 A | 30, 32 | 100% |  |
| 92 | 1.3.2.3.5 | **نقشه‌های برق** | 30.9d | 2026-04-22 A | 2026-05-27 |  | 96% | 68.1d |
| 93 |  | تک‌خطی MV و LV و AUX | 1d | 2026-05-05 A | 2026-05-06 | 77, 78 | 95% | 0.4d |
| 94 |  | سیستم DC شارژر | 1d | 2026-05-06 A | 2026-05-07 | 93 | 95% | 85.8d |
| 95 |  | پلان تجهیزات برق | 1d | 2026-04-22 A | 2026-05-27 | 32 | 95% | 0.95d |
| 96 |  | آرایش تابلوها | 1d | 2026-04-23 A | 2026-04-23 A | 95 | 100% |  |
| 97 | 1.3.2.3.6 | **سیستم اعلام و اطفاء حریق** | 27.9d | 2026-04-28 A | 2026-05-30 |  | 95% | 66.1d |
| 98 |  | دیاگرام بلوکی | 1d | 2026-04-28 A | 2026-04-28 | 65 | 95% | 0.95d |
| 99 |  | دیاگرام لوپ | 1d | 2026-04-29 A | 2026-04-29 | 98 | 95% | 25.85d |
| 100 |  | جانمایی تجهیزات | 1d | 2026-05-27 A | 2026-05-28 | 95 | 95% | 0.95d |
| 101 |  | لیست تجهیزات | 1d | 2026-05-28 A | 2026-05-30 | 99, 100 | 95% | 66.1d |
| 102 | 1.3.2.4 | **ابزار دقیق و کنترل (I&C)** | 30.7d | 2026-04-22 A | 2026-05-27 |  | 82% | 68.3d |
| 103 | 1.3.2.4.1 | **سیستم کنترل** | 3d | 2026-04-28 A | 2026-04-30 |  | 80% | 0.8d |
| 104 |  | فلسفه کنترل | 1d | 2026-04-28 A | 2026-04-28 | 65 | 80% | 0.8d |
| 105 |  | لیست I/O | 1d | 2026-04-29 A | 2026-04-29 | 104 | 80% | 0.8d |
| 106 |  | طراحی RTU | 1d | 2026-04-30 A | 2026-04-30 | 105 | 80% | 0.8d |
| 107 | 1.3.2.4.2 | **ابزار دقیق** | 2d | 2026-04-30 A | 2026-05-02 |  | 80% | 90d |
| 108 |  | دیتاشیت ولوهای کنترلی | 1d | 2026-04-30 A | 2026-04-30 | 65, 67 | 80% | 91d |
| 109 |  | لیست کابل‌های I&C | 1d | 2026-04-30 A | 2026-04-30 | 105 | 80% | 0.9d |
| 110 |  | دیتاشیت تجهیزات خاص | 1d | 2026-05-02 A | 2026-05-02 | 106 | 80% | 90d |
| 111 | 1.3.2.4.3 | **اتاق کنترل** | 30.7d | 2026-04-22 A | 2026-05-27 |  | 80% | 68.3d |
| 112 |  | طراحی اتاق کنترل | 1d | 2026-04-22 A | 2026-05-27 | 32 | 80% | 68.3d |
| 113 | 1.3.2.4.4 | **یکپارچه‌سازی** | 5.2d | 2026-05-02 A | 2026-05-07 |  | 90% | 85.8d |
| 114 |  | متره کابل‌های I&C | 1d | 2026-05-02 A | 2026-05-02 | 109 | 90% | 90d |
| 115 |  | ارتباط با برق | 1d | 2026-05-06 A | 2026-05-07 | 93, 106 | 90% | 85.8d |
| 116 | 1.2 | **تأمین تجهیزات (Procurement)** | 147d | 2026-01-03 A | 2026-06-22 |  | 94% | 46d |
| 117 | 1.2.1 | **مولد گازسوز CAT CG170** | 48d | 2026-04-28 A | 2026-06-22 A |  | 100% |  |
| 118 |  | گشایش اعتبار و سفارش گذاری مولد | 25d | 2026-04-28 A | 2026-05-26 A | 42 | 100% |  |
| 119 |  | فرآیند ساخت در کارخانه CAT | 17d | 2026-05-27 A | 2026-06-15 A | 118 | 100% |  |
| 120 | 1.2.1.3 | **تست کارخانه ای (FAT) مولد و رادیاتور** | 1d | 2026-04-29 | 2026-04-30 | 119 | 100% |  |
| 121 |  | آماده سازی برای تست کارخانه ای (FAT) مولد و رادیاتور | 3d | 2026-06-16 A | 2026-06-18 A | 119 | 100% |  |
| 122 |  | اجرای نهایی و بازرسی تست کارخانه ای (FAT) مولد و رادیاتور | 3d | 2026-06-20 A | 2026-06-22 A | 121 | 100% |  |
| 123 |  | حمل بین المللی و ترخیص گمرکی | 6d | 2026-05-02 A | 2026-05-07 A | 120 | 100% |  |
| 124 |  | تخلیه و انبارش در سایت | 1d | 2026-05-09 A | 2026-05-09 A | 123 | 100% |  |
| 125 | 1.2.2 | **تجهیزات جانبی مولد (Tool kit/Batteries)** | 35d | 2026-04-28 A | 2026-06-07 |  | 90% | 59d |
| 126 |  | تأمین Tool Kit مخصوص کارخانه | 1d | 2026-04-28 A | 2026-04-28 | 42 | 90% | 93d |
| 127 |  | تأمین باتری ها و شارژرها | 10d | 2026-05-27 A | 2026-06-07 | 118 | 90% | 59d |
| 128 |  | تأمین متعلقات نصب و راه اندازی | 10d | 2026-05-27 A | 2026-06-07 | 118 | 90% | 59d |
| 129 | 1.2.3 | **تأمین سیستم های مکانیکی** | 127d | 2026-01-03 A | 2026-05-30 |  | 90% | 66d |
| 130 |  | تأمین تجهیزات (داکت) ورودی هوای احتراق | 3d | 2026-05-02 A | 2026-05-04 A | 71 | 100% |  |
| 131 |  | ساخت و تأمین اجزای دودکش و سایلنسر | 3d | 2026-05-05 A | 2026-05-07 | 130 | 90% | 0.1d |
| 132 |  | تأمین لوله و اتصالات گاز (Gas Train) | 1d | 2026-05-09 A | 2026-05-09 | 131 | 10% | 0.85d |
| 133 |  | تأمین کولر خنک کن هوایی (Radiator) | 1d | 2026-05-10 A | 2026-05-10 A | 132 | 100% |  |
| 134 |  | تامین فن های ورودی / خروجی | 1d | 2026-01-03 A | 2026-01-03 A |  | 100% |  |
| 135 |  | تامین عایق و رنگ | 1d | 2026-01-04 A | 2026-01-04 | 134 | 10% | 191d |
| 136 | 1.2.3.5 | **تأمین پمپ ها و تجهیزات روغنکاری** | 20d | 2026-05-03 A | 2026-05-25 |  | 95% | 0.9d |
| 137 |  | LT Oil Feed | 5d | 2026-05-03 A | 2026-05-07 A | 47 | 100% |  |
| 138 |  | HT Oil Feed | 5d | 2026-05-09 A | 2026-05-13 A | 137 | 100% |  |
| 139 |  | Feed Water | 5d | 2026-05-14 A | 2026-05-19 | 138 | 90% | 4.5d |
| 140 |  | (Utility / Service / Cooling) | 5d | 2026-05-20 A | 2026-05-25 | 139 | 90% | 0.9d |

| ID | WBS | Task | Duration | Start | Finish | Predecessors | Complete | Total float |
| --- | --- | --- | --- | --- | --- | --- | --- | --- |
| 141 |  | تأمین فن ها و دمپرهای تهویه سالن | 4d | 2026-05-26 A | 2026-05-30 | 136 | 90% | 66d |
| 142 | 1.2.4 | **تأمین تجهیزات برقی و کنترل** | 13d | 2026-05-09 A | 2026-05-23 |  | 91% | 72d |
| 143 |  | ساخت تابلوهای مصرف داخلی (Aux) | 3d | 2026-05-09 A | 2026-05-11 |  | 90% | 2.7d |
| 144 |  | تأمین سوئیچگیر MV | 3d | 2026-05-12 A | 2026-05-14 | 143 | 90% | 0.9d |
| 145 |  | خرید کابل های MV و LV | 1d | 2026-05-16 A | 2026-05-16 | 144 | 90% | 0.9d |
| 146 |  | سیستم زمین (ارتینگ ثانویه) | 1d | 2026-05-17 A | 2026-05-17 | 145 | 90% | 0.9d |
| 147 |  | تأمین سینی کابل و کاندوئیت ها | 1d | 2026-05-17 A | 2026-05-17 | 145 | 90% | 0.9d |
| 148 |  | تأمین تجهیزات ابزاردقیق و مانیتورینگ | 1d | 2026-05-18 A | 2026-05-18 | 147 | 90% | 3.8d |
| 149 |  | تامین تابلو gcp | 1d | 2026-05-18 A | 2026-05-18 | 146 | 90% | 2.7d |
| 150 |  | تأمین Bulk Material | 3d | 2026-05-19 A | 2026-05-21 | 149 | 90% | 73d |
| 151 |  | تأمین سیستم Gas Detection | 4d | 2026-05-19 A | 2026-05-23 | 148 | 95% | 23.4d |
| 152 | 1.3 | **عملیات اجرایی (Construction)** | 62d | 2026-04-25 A | 2026-07-05 |  | 95% | 0d |
| 153 | 1.3.1 | **عملیات سیویل و آماده سازی** | 50d | 2026-04-25 A | 2026-06-21 |  | 99% | 12d |
| 154 | 1.3.1.1 | **خاکبرداری و تسطیح محل نصب** | 26d | 2026-04-25 A | 2026-05-24 A |  | 100% |  |
| 155 |  | آماده سازی برای خاکبرداری و تسطیح محل نصب | 1d | 2026-04-25 A | 2026-04-25 A |  | 100% |  |
| 156 |  | اجرای نهایی و بازرسی خاکبرداری و تسطیح محل نصب | 1d | 2026-05-24 A | 2026-05-24 A | 155, 151 | 100% |  |
| 157 | 1.3.1.2 | **فونداسیون‌ها و سازه‌های تجهیزات خاص** | 23d | 2026-05-24 A | 2026-06-18 A |  | 100% |  |
| 158 |  | فونداسیون و سازه رادیاتور | 9d | 2026-05-25 A | 2026-06-03 A | 154, 151 | 100% |  |
| 159 |  | فونداسیون و سازه مافلر | 9d | 2026-05-24 A | 2026-06-02 A | 151 | 100% |  |
| 160 |  | فونداسیون مخزن آب میک‌آپ | 9d | 2026-06-01 A | 2026-06-10 A | 159, 151 | 100% |  |
| 161 |  | فونداسیون مخزن روغن ترانسفورماتور | 9d | 2026-06-09 A | 2026-06-18 A | 160, 151 | 100% |  |
| 162 | 1.3.1.3 | **عملیات تخریب و اصلاح سازه موجود** | 21.5d | 2026-05-26 A | 2026-06-20 |  | 96% | 13.5d |
| 163 |  | بررسی وضعیت شلتر و سقف موجود | 1d | 2026-06-17 A | 2026-06-20 | 157, 151 | 90% | 13.5d |
| 164 |  | ایمن‌سازی و آماده‌سازی محل کار | 1d | 2026-05-26 A | 2026-05-26 | 140 | 90% | 34d |
| 165 |  | باز کردن و جمع‌آوری سقف شلتر موجود | 1d | 2026-05-27 A | 2026-05-27 A | 164, 151 | 100% |  |
| 166 |  | حمل و جمع‌آوری مصالح سقف قبلی | 1d | 2026-05-28 A | 2026-05-28 A | 165 | 100% |  |
| 167 |  | کنترل سازه و آماده‌سازی برای اجرای سقف جدید | 1d | 2026-05-30 A | 2026-05-30 A | 166 | 100% |  |
| 168 | 1.3.1.4 | **اجرای سقف جدید و اصلاح معماری** | 23d | 2026-05-26 A | 2026-06-21 A |  | 100% |  |
| 169 |  | اجرای سقف مسطح موقت | 1d | 2026-05-26 A | 2026-05-26 A | 140 | 100% |  |
| 170 |  | اجرای سازه نگهدارنده سقف نهایی | 1d | 2026-05-30 A | 2026-05-30 A | 169, 166 | 100% |  |
| 171 |  | نصب شلتر سقف نهایی | 1d | 2026-05-31 A | 2026-05-31 A | 170, 166 | 100% |  |
| 172 |  | آب‌بندی و عایق‌کاری سقف | 1d | 2026-06-20 A | 2026-06-20 A | 157, 166 | 100% |  |
| 173 |  | تست بارگذاری و کنترل سازه سقف | 1d | 2026-06-21 A | 2026-06-21 A | 172, 166 | 100% |  |
| 174 | 1.3.2 | **نصب تجهیزات مکانیکی** | 41d | 2026-05-10 A | 2026-06-25 |  | 92% | 8d |
| 175 | 1.3.2.1 | **استقرار و تراز مولد روی فونداسیون** | 2d | 2026-06-17 A | 2026-06-18 A |  | 100% |  |
| 176 |  | آماده سازی برای استقرار و تراز مولد روی فونداسیون | 1d | 2026-06-17 A | 2026-06-17 A | 161 | 100% |  |
| 177 |  | اجرای نهایی و بازرسی استقرار و تراز مولد روی فونداسیون | 1d | 2026-06-18 A | 2026-06-18 A | 176 | 100% |  |
| 178 | 1.3.2.2 | **نصب رادیاتور و سیستم خنک کن** | 1d | 2026-06-20 A | 2026-06-20 A |  | 100% |  |
| 179 |  | آماده سازی برای نصب رادیاتور و سیستم خنک کن | 1d | 2026-06-20 A | 2026-06-20 A | 133, 175 | 100% |  |
| 180 |  | اجرای نهایی و بازرسی نصب رادیاتور و سیستم خنک کن | 1d | 2026-06-20 A | 2026-06-20 A | 133, 175, 177 | 100% |  |
| 181 | 1.3.2.3 | **نصب سیستم دودکش و سایلنسر** | 2d | 2026-06-20 A | 2026-06-21 A |  | 100% |  |
| 182 |  | آماده سازی برای نصب سیستم دودکش و سایلنسر | 1d | 2026-06-20 A | 2026-06-20 A | 131, 175, 177 | 100% |  |
| 183 |  | اجرای نهایی و بازرسی نصب سیستم دودکش و سایلنسر | 1d | 2026-06-21 A | 2026-06-21 A | 182, 177 | 100% |  |
| 184 | 1.5.2.4 | **اجرای پایپینگ مربوط به پمپ‌ها** | 22d | 2026-05-30 A | 2026-06-23 |  | 92% | 10d |
| 185 | 1.5.2.4.1 | **آماده‌سازی نصب** | 22d | 2026-05-30 A | 2026-06-23 A |  | 100% |  |
| 186 |  | تحویل فونداسیون پمپ‌ها از سیویل | 1d | 2026-05-30 A | 2026-05-30 A | 166 | 100% |  |
| 187 |  | چک‌لیست تراز و انکر بولت‌ها | 1d | 2026-06-22 A | 2026-06-22 A | 186, 183 | 100% |  |
| 188 |  | آماده‌سازی محل نصب | 1d | 2026-06-23 A | 2026-06-23 A | 187, 186 | 100% |  |
| 189 | 1.5.2.4.2 | **نصب مکانیکی پمپ‌ها** | 4d | 2026-05-31 A | 2026-06-03 |  | 93% | 0.8d |
| 190 |  | نصب پمپ LT Oil Feed | 1d | 2026-05-31 A | 2026-05-31 A | 186 | 100% |  |
| 191 |  | نصب پمپ HT Oil Feed | 1d | 2026-06-01 A | 2026-06-01 A | 190, 186 | 100% |  |
| 192 |  | نصب پمپ Feed Water | 1d | 2026-06-02 A | 2026-06-02 | 191, 186 | 85% | 0.85d |
| 193 |  | نصب سایر پمپ‌ها | 1d | 2026-06-03 A | 2026-06-03 | 192, 186 | 85% | 0.8d |
| 194 | 1.5.2.4.3 | **اجرای پایپینگ ورودی/خروجی پمپ‌ها** | 5d | 2026-06-04 A | 2026-06-09 |  | 85% | 22d |
| 195 |  | suction پمپ‌ها oil | 1d | 2026-06-04 A | 2026-06-04 | 189 | 80% | 0.8d |
| 196 |  | discharge پمپ‌ها oil | 1d | 2026-06-06 A | 2026-06-06 | 195 | 80% | 1.9d |
| 197 |  | نصب ولوها و استرینرها | 1d | 2026-06-08 A | 2026-06-08 | 196 | 90% | 0.9d |
| 198 |  | نصب ساپورت‌های لوله | 1d | 2026-06-09 A | 2026-06-09 | 197 | 90% | 22d |
| 199 | 1.3.2.4 | **اجرای پایپینگ گاز و Gas Train** | 2d | 2026-05-10 A | 2026-05-11 |  | 85% | 39.8d |
| 200 |  | آماده سازی برای اجرای پایپینگ گاز و Gas Train | 1d | 2026-05-10 A | 2026-05-10 | 132 | 85% | 0.85d |
| 201 |  | اجرای نهایی و بازرسی اجرای پایپینگ گاز و Gas Train | 1d | 2026-05-11 A | 2026-05-11 | 200 | 85% | 39.8d |
| 202 | 1.3.2.5 | **اجرای پایپینگ آب خنک کن** | 2d | 2026-06-21 A | 2026-06-22 |  | 90% | 3.9d |
| 203 |  | آماده سازی برای اجرای پایپینگ آب خنک کن | 1d | 2026-06-21 A | 2026-06-21 | 133, 178, 186 | 90% | 0.9d |
| 204 |  | اجرای نهایی و بازرسی اجرای پایپینگ آب خنک کن | 1d | 2026-06-22 A | 2026-06-22 | 203, 186 | 90% | 3.9d |
| 205 | 1.3.2.6 | **نصب سیستم های روغنکاری و مخازن** | 2d | 2026-05-31 A | 2026-06-01 |  | 90% | 29d |
| 206 |  | آماده سازی برای نصب سیستم های روغنکاری و مخازن | 1d | 2026-05-31 A | 2026-05-31 | 186 | 90% | 0.9d |
| 207 |  | اجرای نهایی و بازرسی نصب سیستم های روغنکاری و مخازن | 1d | 2026-06-01 A | 2026-06-01 | 206 | 90% | 29d |
| 208 | 1.3.2.7 | **نصب تجهیزات تهویه و فن های سالن** | 2d | 2026-05-31 A | 2026-06-01 |  | 90% | 29d |
| 209 |  | آماده سازی برای نصب تجهیزات تهویه و فن های سالن | 1d | 2026-05-31 A | 2026-05-31 | 186 | 90% | 0.9d |
| 210 |  | اجرای نهایی و بازرسی نصب تجهیزات تهویه و فن های سالن | 1d | 2026-06-01 A | 2026-06-01 | 209 | 90% | 29d |

| ID | WBS | Task | Duration | Start | Finish | Predecessors | Complete | Total float |
| --- | --- | --- | --- | --- | --- | --- | --- | --- |
| 211 | 1.3.2.8 | **عایق کاری لوله های داغ و اگزوز** | 2d | 2026-06-22 A | 2026-06-23 |  | 90% | 0.9d |
| 212 |  | آماده سازی برای عایق کاری لوله های داغ و اگزوز | 1d | 2026-06-22 A | 2026-06-22 | 181, 186 | 90% | 0.9d |
| 213 |  | اجرای نهایی و بازرسی عایق کاری لوله های داغ و اگزوز | 1d | 2026-06-23 A | 2026-06-23 | 212, 186 | 90% | 0.9d |
| 214 | 1.3.2.9 | **رنگ آمیزی و پوشش نهایی تجهیزات** | 2d | 2026-06-24 A | 2026-06-25 |  | 90% | 0.8d |
| 215 |  | آماده سازی برای رنگ آمیزی و پوشش نهایی تجهیزات | 1d | 2026-06-24 A | 2026-06-24 | 211, 166 | 90% | 0.9d |
| 216 |  | اجرای نهایی و بازرسی رنگ آمیزی و پوشش نهایی تجهیزات | 1d | 2026-06-25 A | 2026-06-25 | 215, 166 | 90% | 0.8d |
| 217 | 1.3.3 | **اجرای سیستم های برقی** | 8d | 2026-06-27 A | 2026-07-05 |  | 89% | 0d |
| 218 | 1.3.3.1 | **اجرای شبکه زمین و ارتینگ ثانویه** | 2d | 2026-06-27 A | 2026-06-28 |  | 90% | 6d |
| 219 |  | آماده سازی برای اجرای شبکه زمین و ارتینگ ثانویه | 1d | 2026-06-27 A | 2026-06-27 | 216 | 90% | 0.9d |
| 220 |  | اجرای نهایی و بازرسی اجرای شبکه زمین و ارتینگ ثانویه | 1d | 2026-06-28 A | 2026-06-28 | 219 | 90% | 6d |
| 221 | 1.3.3.2 | **نصب سینی کابل و نردبان کابل** | 2d | 2026-06-27 A | 2026-06-28 |  | 90% | 0.9d |
| 222 |  | آماده سازی برای نصب سینی کابل و نردبان کابل | 1d | 2026-06-27 A | 2026-06-27 | 216 | 90% | 0.9d |
| 223 |  | اجرای نهایی و بازرسی نصب سینی کابل و نردبان کابل | 1d | 2026-06-28 A | 2026-06-28 | 222 | 90% | 0.9d |
| 224 | 1.3.3.3 | **نصب تابلوهای فشار متوسط (MV)** | 2d | 2026-06-27 A | 2026-06-28 |  | 90% | 6d |
| 225 |  | آماده سازی برای نصب تابلوهای فشار متوسط (MV) | 1d | 2026-06-27 A | 2026-06-27 | 216 | 90% | 0.9d |
| 226 |  | اجرای نهایی و بازرسی نصب تابلوهای فشار متوسط (MV) | 1d | 2026-06-28 A | 2026-06-28 | 225 | 90% | 6d |
| 227 | 1.3.3.4 | **نصب تابلوهای فشار ضعیف و مصرف داخلی** | 2d | 2026-06-27 A | 2026-06-28 |  | 90% | 0.9d |
| 228 |  | آماده سازی برای نصب تابلوهای فشار ضعیف و مصرف داخلی | 1d | 2026-06-27 A | 2026-06-27 | 143, 216 | 90% | 0.9d |
| 229 |  | اجرای نهایی و بازرسی نصب تابلوهای فشار ضعیف و مصرف داخلی | 1d | 2026-06-28 A | 2026-06-28 | 228, 216 | 90% | 0.9d |
| 230 | 1.3.3.5 | **کابل کشی قدرت (MV/LV)** | 4d | 2026-06-29 A | 2026-07-02 |  | 88% | 0.9d |
| 231 |  | آماده سازی برای کابل کشی قدرت (MV/LV) | 1d | 2026-06-29 A | 2026-06-29 | 229 | 90% | 0.8d |
| 232 |  | اجرای نهایی و بازرسی کابل کشی قدرت (MV/LV) | 1d | 2026-06-30 A | 2026-06-30 | 231 | 80% | 0.9d |
| 233 |  | آماده سازی برای کابل کشی aux | 1d | 2026-07-01 A | 2026-07-01 | 232 | 90% | 0.9d |
| 234 |  | اجرای نهایی و بازرسی کابل کشی aux | 1d | 2026-07-02 A | 2026-07-02 | 233 | 90% | 0.9d |
| 235 | 1.3.3.6 | **کابل کشی کنترل و ابزاردقیق** | 2d | 2026-06-29 A | 2026-06-30 |  | 90% | 2.9d |
| 236 |  | آماده سازی برای کابل کشی کنترل و ابزاردقیق | 1d | 2026-06-29 A | 2026-06-29 | 221, 145, 229 | 90% | 0.9d |
| 237 |  | اجرای نهایی و بازرسی کابل کشی کنترل و ابزاردقیق | 1d | 2026-06-30 A | 2026-06-30 | 236, 229 | 90% | 2.9d |
| 238 | 1.3.3.7 | **سربندی (Termination) کابل ها** | 2d | 2026-07-04 A | 2026-07-05 |  | 90% | 0d |
| 239 |  | آماده سازی برای سربندی (Termination) کابل ها | 1d | 2026-07-04 A | 2026-07-04 | 230, 235, 229 | 90% | 0.9d |
| 240 |  | اجرای نهایی و بازرسی سربندی (Termination) کابل ها | 1d | 2026-07-05 A | 2026-07-05 | 239, 229 | 90% | 0d |
| 241 | 1.3.4 | **نصب ابزاردقیق و کنترل** | 1d | 2026-06-27 A | 2026-06-27 |  | 85% | 7d |
| 242 | 1.3.4.1 | **نصب تجهیزات مانیتورینگ موتور** | 1d | 2026-06-27 A | 2026-06-27 |  | 90% | 7d |
| 243 |  | آماده سازی برای نصب تجهیزات مانیتورینگ موتور | 1d | 2026-06-27 A | 2026-06-27 | 175, 216 | 90% | 7d |
| 244 |  | اجرای نهایی و بازرسی نصب تجهیزات مانیتورینگ موتور | 0d | 2026-06-27 A | 2026-06-27 | 243, 216 | 90% | 7d |
| 245 | 1.3.4.2 | **نصب سنسورها و تجهیزات فیلد** | 1d | 2026-06-27 A | 2026-06-27 |  | 90% | 7d |
| 246 |  | آماده سازی برای نصب سنسورها و تجهیزات فیلد | 1d | 2026-06-27 A | 2026-06-27 | 199, 202, 216 | 90% | 7d |
| 247 |  | اجرای نهایی و بازرسی نصب سنسورها و تجهیزات فیلد | 0d | 2026-06-27 A | 2026-06-27 | 246, 216 | 90% | 7d |
| 248 | 1.3.4.3 | **نصب سیستم Gas Detection** | 1d | 2026-06-27 A | 2026-06-27 |  | 80% | 7d |
| 249 |  | آماده سازی برای نصب سیستم Gas Detection | 1d | 2026-06-27 A | 2026-06-27 | 199, 216 | 80% | 7d |
| 250 |  | اجرای نهایی و بازرسی نصب سیستم Gas Detection | 0d | 2026-06-27 A | 2026-06-27 | 249, 216 | 80% | 7d |
| 251 | 1.3.4.4 | **نصب و پیکربندی سیستم کنترل مرکزی** | 1d | 2026-06-27 A | 2026-06-27 |  | 80% | 7d |
| 252 |  | آماده سازی برای نصب و پیکربندی سیستم کنترل مرکزی | 1d | 2026-06-27 A | 2026-06-27 | 148, 216 | 80% | 7d |
| 253 |  | اجرای نهایی و بازرسی نصب و پیکربندی سیستم کنترل مرکزی | 0d | 2026-06-27 A | 2026-06-27 | 252, 216 | 80% | 7d |
| 254 | 1.4 | **تست و راه اندازی (Commissioning)** | 5d | 2026-07-06 A | 2026-07-11 |  | 4% | 0d |
| 255 | 1.4.1 | **تست های پیش راه اندازی (Pre-Comm)** | 4d | 2026-07-06 A | 2026-07-09 |  | 50% | 1d |
| 256 |  | چک‌لیست‌های نصب تجهیزات | 4d | 2026-07-06 A | 2026-07-09 | 152 | 50% | 1d |
| 257 |  | تست عایقی و پیوستگی کابل ها | 4d | 2026-07-06 A | 2026-07-09 | 152 | 50% | 0d |
| 258 |  | تمیزکاری و فلاشینگ سیستم‌ها | 4d | 2026-07-06 A | 2026-07-09 | 152 | 50% | 1d |
| 259 | 1.6.2 | **تست ترانسفورماتور** | 4d | 2026-07-06 | 2026-07-09 |  |  | 1d |
| 260 |  | تست نسبت تبدیل (TTR Test) | 4d | 2026-07-06 | 2026-07-09 | 152 |  | 1d |
| 261 |  | تست عایقی (IR / Megger Test) | 4d | 2026-07-06 | 2026-07-09 | 152 |  | 1d |
| 262 |  | تست روغن ترانس (BDV & DGA) | 4d | 2026-07-06 | 2026-07-09 | 152 |  | 1d |
| 263 |  | تست عملکرد بی‌بار (No Load Test) | 4d | 2026-07-06 | 2026-07-09 | 152 |  | 1d |
| 264 |  | تست تحت بار (Load Test) | 4d | 2026-07-06 | 2026-07-09 | 152 |  | 1d |
| 265 | 1.6.3 | **تست ژنراتور / مولد** | 4d | 2026-07-06 | 2026-07-09 |  |  | 1d |
| 266 |  | تست عایقی ژنراتور | 4d | 2026-07-06 | 2026-07-09 | 152 |  | 1d |
| 267 |  | تست مدار تحریک | 4d | 2026-07-06 | 2026-07-09 | 152 |  | 1d |
| 268 |  | تست سنکرونیزاسیون | 4d | 2026-07-06 | 2026-07-09 | 152 |  | 1d |
| 269 |  | تست بی‌بار | 4d | 2026-07-06 | 2026-07-09 | 152 |  | 1d |
| 270 |  | تست تحت بار کامل (Full Load Test) | 4d | 2026-07-06 | 2026-07-09 | 152 |  | 1d |
| 271 |  | تست حفاظت‌ها (Protection Test) | 4d | 2026-07-06 | 2026-07-09 | 152 |  | 1d |
| 272 | 1.6.4 | **تست رادیاتور و سیستم خنک‌کاری** | 4d | 2026-07-06 | 2026-07-09 |  |  | 1d |
| 273 |  | تست فشار (Pressure Test) | 4d | 2026-07-06 | 2026-07-09 | 152 |  | 1d |
| 274 |  | تست نشتی (Leak Test) | 4d | 2026-07-06 | 2026-07-09 | 152 |  | 1d |
| 275 |  | تست عملکرد فن‌ها | 4d | 2026-07-06 | 2026-07-09 | 152 |  | 1d |
| 276 |  | تست گردش سیال خنک‌کننده | 4d | 2026-07-06 | 2026-07-09 | 152 |  | 1d |
| 277 |  | تست عملکرد در بار نامی | 4d | 2026-07-06 | 2026-07-09 | 152 |  | 1d |
| 278 | 1.6.5 | **تست سوئیچگیر (MV / LV Switchgear)** | 4d | 2026-07-06 | 2026-07-09 |  |  | 1d |
| 279 |  | تست عایقی (IR Test) | 4d | 2026-07-06 | 2026-07-09 | 152 |  | 1d |
| 280 |  | تست عملکرد بریکرها | 4d | 2026-07-06 | 2026-07-09 | 152 |  | 1d |

| ID | WBS | Task | Duration | Start | Finish | Predecessors | Total float |
| --- | --- | --- | --- | --- | --- | --- | --- |
| 281 |  | تست اینترلاک‌ها | 4d | 2026-07-06 | 2026-07-09 | 152 | 1d |
| 282 |  | تست رله‌های حفاظتی | 4d | 2026-07-06 | 2026-07-09 | 152 | 1d |
| 283 |  | تست قطع و وصل تحت بار | 4d | 2026-07-06 | 2026-07-09 | 152 | 1d |
| 284 |  | تست هماهنگی حفاظتی | 4d | 2026-07-06 | 2026-07-09 | 152 | 1d |
| 285 |  | تست تابلو gcp و aux | 4d | 2026-07-06 | 2026-07-09 | 152 | 1d |
| 286 | 1.6.6 | **تست سیستم کولینگ (Cooling System) سالن موتور** | 4d | 2026-07-06 | 2026-07-09 |  | 0d |
| 287 |  | تست پمپ‌های سیستم خنک‌کاری | 4d | 2026-07-06 | 2026-07-09 | 152 | 1d |
| 288 |  | تست مدار لوله‌کشی خنک‌کاری | 4d | 2026-07-06 | 2026-07-09 | 152 | 0d |
| 289 |  | تست عملکرد مبدل‌های حرارتی | 4d | 2026-07-06 | 2026-07-09 | 152 | 1d |
| 290 |  | تست دبی و فشار سیستم | 4d | 2026-07-06 | 2026-07-09 | 152 | 1d |
| 291 |  | تست عملکرد در شرایط عملیاتی | 4d | 2026-07-06 | 2026-07-09 | 152 | 1d |
| 292 | 1.6.7 | **تست‌های یکپارچه (Integrated Tests)** | 4d | 2026-07-06 | 2026-07-09 |  | 1d |
| 293 |  | تست بدون بار کل واحد (No Load Test Run) | 4d | 2026-07-06 | 2026-07-09 | 152 | 1d |
| 294 |  | تست سنکرون کل سیستم | 4d | 2026-07-06 | 2026-07-09 | 152 | 1d |
| 295 |  | تست Load Acceptance | 4d | 2026-07-06 | 2026-07-09 | 152 | 1d |
| 296 |  | تست Trip و Emergency Shutdown | 4d | 2026-07-06 | 2026-07-09 | 152 | 1d |
| 297 |  | تست عملکرد سیستم‌های کمکی | 4d | 2026-07-06 | 2026-07-09 | 152 | 1d |
| 298 | 1.4.1.3 | **Cold Loop Test ابزاردقیق** | 1d | 2026-07-06 | 2026-07-06 |  | 4d |
| 299 |  | آماده سازی برای Cold Loop Test ابزاردقیق | 1d | 2026-07-06 | 2026-07-06 | 152 | 4d |
| 300 |  | اجرای نهایی و بازرسی Cold Loop Test ابزاردقیق | 1d | 2026-07-06 | 2026-07-06 | 152 | 4d |
| 301 | 1.4.2 | **راه اندازی (Commissioning)** | 1d | 2026-07-11 | 2026-07-11 |  | 0d |
| 302 |  | برق دار کردن تابلوهای داخلی | 1d | 2026-07-11 | 2026-07-11 | 257, 288 | 0d |
| 303 |  | تست عملکردی سیستم سوخت رسانی | 1d | 2026-07-11 | 2026-07-11 | 302SS | 0d |
| 304 |  | استارت اولیه مولد بدون بار | 1d | 2026-07-11 | 2026-07-11 | 302SS | 0d |
| 305 |  | تست پارالل و سنکرون سازی | 1d | 2026-07-11 | 2026-07-11 | 302SS | 0d |
| 306 |  | تست عملکردی زیر بار (Load Test) | 1d | 2026-07-11 | 2026-07-11 | 302SS | 0d |
| 307 |  | تست نهایی سیستم Gas Detection | 1d | 2026-07-11 | 2026-07-11 | 302SS | 0d |
| 308 | 1.5 | **تحویل و بهره برداری (Close-out)** | 30d | 2026-07-12 | 2026-08-15 |  | 0d |
| 309 | 1.5.1 | **بهره برداری آزمایشی** | 17d | 2026-07-12 | 2026-07-30 |  | 0d |
| 310 |  | دوره 72 ساعته تست مداوم | 1d | 2026-07-12 | 2026-07-12 | 254 | 0d |
| 311 |  | رفع نواقص احتمالی (Punch List) | 16d | 2026-07-13 | 2026-07-30 | 310 | 0d |
| 312 | 1.5.2 | **مستندات و تحویل** | 13d | 2026-08-01 | 2026-08-15 |  | 0d |
| 313 |  | تهیه نقشه های As-Built | 2d | 2026-08-01 | 2026-08-02 | 311 | 0d |
| 314 |  | آموزش تیم بهره بردار کارفرما | 3d | 2026-08-03 | 2026-08-05 | 313 | 0d |
| 315 |  | تحویل موقت (PAC) | 7d | 2026-08-06 | 2026-08-13 | 314 | 0d |
| 316 |  | شروع دوره بهره برداری (Operation) | 1d | 2026-08-15 | 2026-08-15 | 315 | 0d |
| 317 |  | پایان | 0d | 2026-08-15 | 2026-08-15 | 316, 297, 300, 291, 284, 277, 271, 94, 36, 50 | 0d |

## Version 2 (data date 2026-10-03, saved 2026-07-13, file نهایی.mpp)

Last finish stays 2026-08-15. Complete tasks 60 → 229.

Changed:

| ID | Task | Finish | Complete | Total float |
| --- | --- | --- | --- | --- |
| 1 | **پروژه احداث نیروگاه گازسوز 2000 کیلووات (CAT CG170)** | 2026-08-15 A | 67% → 100% | 0d → none |
| 7 | **مهندسی و طراحی (Engineering)** | 2026-06-03 A | 94% → 100% | 62.6d → none |
| 8 | **طراحی پایه (Basic Design)** | 2026-06-03 A | 95% → 100% | 62.6d → none |
| 9 | تهیه نقشه های جانمایی (General Layout) | 2026-05-26 A | 95% → 100% | 0.15d → none |
| 10 | تهیه نمودارهای P&ID سیستم های مکانیک | 2026-05-27 A | 95% → 100% | 2.3d → none |
| 11 | **طراحی تک خطی دیاگرام های برقی (SLD)** | 2026-06-03 A | 95% → 100% | 62.6d → none |
| 12 | آماده سازی برای طراحی تک خطی دیاگرام های برقی (SLD) | 2026-05-31 A | 95% → 100% | 2.5d → none |
| 13 | اجرای نهایی و بازرسی طراحی تک خطی دیاگرام های برقی (SLD) | 2026-06-03 A | 95% → 100% | 62.6d → none |
| 14 | **مهندسی تفصیلی (Detail Design)** | 2026-05-30 A | 94% → 100% | 66.1d → none |
| 15 | **مهندسی عمران و سازه** | 2026-05-28 A | 97% → 100% | 67.6d → none |
| 16 | **طراحی عمومی سایت** | 2026-05-27 A | 95% → 100% | 0.05d → none |
| 17 | پلان کلی سایت (Plot Plan) | 2026-05-27 A | 95% → 100% | 0.05d → none |
| 18 | **طراحی فونداسیون‌ها** | 2026-04-20 A | 99% → 100% | 100d → none |
| 22 | فونداسیون ایرکولر | 2026-04-20 A | 95% → 100% | 100d → none |
| 24 | **سیستم‌های زیرزمینی** | 2026-05-28 A | 94% → 100% | 67.6d → none |
| 25 | طراحی کانال کابل | 2026-05-27 A | 95% → 100% | 0.15d → none |
| 26 | طراحی ترانشه لوله | 2026-05-27 A | 95% → 100% | 0.15d → none |
| 27 | طراحی پایپ اسلیپر | 2026-05-27 A | 95% → 100% | 68.2d → none |
| 28 | طراحی چاه‌های ارت | 2026-05-28 A | 90% → 100% | 0.95d → none |
| 29 | **ساختمان‌ها و معماری** | 2026-05-27 A | 95% → 100% | 68.5d → none |
| 30 | معماری سالن موتور | 2026-05-27 A | 95% → 100% | 0.15d → none |
| 31 | معماری شلتر (نما، مقطع، جزئیات) | 2026-05-27 A | 95% → 100% | 68.5d → none |
| 32 | ساختمان CCB / اتاق کنترل / سوئیچگی | 2026-05-27 A | 95% → 100% | 0d → none |
| 33 | **جزئیات سازه‌ای** | 2026-04-23 A | 98% → 100% | 97d → none |
| 36 | سازه های نصب تجهیزات مکانیکی | 2026-04-23 A | 95% → 100% | 97d → none |
| 37 | **مهندسی مکانیک** | 2026-05-27 A | 94% → 100% | 68.3d → none |
| 41 | **تجهیزات دوار** | 2026-05-02 A | 90% → 100% | 90d → none |
| 43 | **مهندسی و خرید پمپ‌ها** | 2026-05-02 A | 88% → 100% | 90d → none |
| 47 | تهیه دیتاشیت سایر پمپ‌ها (Utility / Service / Cooling) | 2026-05-02 A | 50% → 100% | 90d → none |
| 48 | **تجهیزات ثابت** | 2026-05-27 A | 98% → 100% | 68.3d → none |
| 50 | سیستم تهویه و فن‌ها | 2026-05-27 A | 95% → 100% | 68.3d → none |
| 51 | **مهندسی پایپینگ** | 2026-05-02 A | 91% → 100% | 90d → none |
| 52 | نقشه‌های آرایش لوله (GA) | 2026-04-28 A | 90% → 100% | 0.8d → none |
| 53 | نقشه‌های ایزومتریک | 2026-04-29 A | 80% → 100% | 0.95d → none |
| 54 | نقشه‌های ساپورت لوله | 2026-04-30 A | 95% → 100% | 91d → none |
| 55 | متره و برآورد لوله‌ها (MTO) | 2026-04-30 A | 95% → 100% | 0.95d → none |
| 56 | عایق‌کاری و پوشش | 2026-05-02 A | 95% → 100% | 90d → none |
| 57 | **سیستم‌های جانبی** | 2026-04-30 A | 95% → 100% | 91d → none |
| 58 | سیستم خنک‌کاری | 2026-04-29 A | 95% → 100% | 0.95d → none |
| 59 | سیستم روغن‌کاری | 2026-04-30 A | 95% → 100% | 91d → none |
| 60 | سیستم اگزاست | 2026-04-30 A | 95% → 100% | 91d → none |
| 61 | سیستم هوای سالن | 2026-04-30 A | 95% → 100% | 91d → none |
| 62 | **مهندسی فرآیند** | 2026-04-29 A | 93% → 100% | 0.8d → none |
| 63 | **طراحی فرآیند** | 2026-04-29 A | 93% → 100% | 0.8d → none |
| 65 | تهیه P&ID | 2026-04-27 A | 90% → 100% | 0.8d → none |
| 66 | محاسبات هیدرولیکی | 2026-04-28 A | 90% → 100% | 0.9d → none |
| 67 | سایزینگ خطوط | 2026-04-29 A | 90% → 100% | 0.8d → none |
| 68 | **دیتاشیت‌ و اسپک** | 2026-04-30 A | 98% → 100% | 91d → none |
| 71 | سیستم خنک کاری (مولد و سالن) | 2026-04-30 A | 95% → 100% | 91d → none |
| 72 | **مستندات بهره‌برداری** | 2026-04-28 A | 96% → 100% | 93d → none |
| 73 | دستورالعمل بهره‌برداری | 2026-04-28 A | 96% → 100% | 93d → none |
| 74 | **مهندسی برق** | 2026-05-30 A | 95% → 100% | 66.1d → none |
| 75 | **سیستم قدرت** | 2026-05-06 A | 95% → 100% | 86.5d → none |
| 76 | دیتا شیت و اسپک ترانسفورماتور قدرت | 2026-05-04 A | 95% → 100% | 0.45d → none |
| 77 | دیتا شیت و اسپک سوئیچگیر MV | 2026-05-06 A | 95% → 100% | 0.15d → none |
| 78 | AUX دیتا شیت و اسپک | 2026-05-05 A | 95% → 100% | 0.45d → none |
| 79 | تابلوهای توزیع LV دیتا شیت و اسپک | 2026-05-05 A | 95% → 100% | 87d → none |
| 80 | **مطالعات سیستم قدرت** | 2026-05-09 A | 90% → 100% | 84d → none |
| 81 | مطالعات اتصال کوتاه | 2026-05-06 A | 90% → 100% | 0.9d → none |
| 82 | مطالعات پخش بار | 2026-05-07 A | 90% → 100% | 0.9d → none |
| 83 | مطالعات اتصال به شبکه | 2026-05-09 A | 90% → 100% | 84d → none |
| 84 | **کابل‌کشی** | 2026-05-06 A | 98% → 100% | 86d → none |
| 87 | طراحی سینی کابل | 2026-05-05 A | 95% → 100% | 0.95d → none |
| 88 | کابل‌ها (MTO) و سینی ها | 2026-05-06 A | 95% → 100% | 86d → none |
| 89 | **ارت و روشنایی** | 2026-05-30 A | 98% → 100% | 66.6d → none |
| 90 | طراحی سیستم ارتینگ | 2026-05-30 A | 95% → 100% | 66.6d → none |
| 92 | **نقشه‌های برق** | 2026-05-27 A | 96% → 100% | 68.1d → none |
| 93 | تک‌خطی MV و LV و AUX | 2026-05-06 A | 95% → 100% | 0.4d → none |
| 94 | سیستم DC شارژر | 2026-05-07 A | 95% → 100% | 85.8d → none |
| 95 | پلان تجهیزات برق | 2026-05-27 A | 95% → 100% | 0.95d → none |

| ID | Task | Finish | Complete | Total float |
| --- | --- | --- | --- | --- |
| 97 | **سیستم اعلام و اطفاء حریق** | 2026-05-30 A | 95% → 100% | 66.1d → none |
| 98 | دیاگرام بلوکی | 2026-04-28 A | 95% → 100% | 0.95d → none |
| 99 | دیاگرام لوپ | 2026-04-29 A | 95% → 100% | 25.85d → none |
| 100 | جانمایی تجهیزات | 2026-05-28 A | 95% → 100% | 0.95d → none |
| 101 | لیست تجهیزات | 2026-05-30 A | 95% → 100% | 66.1d → none |
| 102 | **ابزار دقیق و کنترل (I&C)** | 2026-05-27 A | 82% → 100% | 68.3d → none |
| 103 | **سیستم کنترل** | 2026-04-30 A | 80% → 100% | 0.8d → none |
| 104 | فلسفه کنترل | 2026-04-28 A | 80% → 100% | 0.8d → none |
| 105 | لیست I/O | 2026-04-29 A | 80% → 100% | 0.8d → none |
| 106 | طراحی RTU | 2026-04-30 A | 80% → 100% | 0.8d → none |
| 107 | **ابزار دقیق** | 2026-05-02 A | 80% → 100% | 90d → none |
| 108 | دیتاشیت ولوهای کنترلی | 2026-04-30 A | 80% → 100% | 91d → none |
| 109 | لیست کابل‌های I&C | 2026-04-30 A | 80% → 100% | 0.9d → none |
| 110 | دیتاشیت تجهیزات خاص | 2026-05-02 A | 80% → 100% | 90d → none |
| 111 | **اتاق کنترل** | 2026-05-27 A | 80% → 100% | 68.3d → none |
| 112 | طراحی اتاق کنترل | 2026-05-27 A | 80% → 100% | 68.3d → none |
| 113 | **یکپارچه‌سازی** | 2026-05-07 A | 90% → 100% | 85.8d → none |
| 114 | متره کابل‌های I&C | 2026-05-02 A | 90% → 100% | 90d → none |
| 115 | ارتباط با برق | 2026-05-07 A | 90% → 100% | 85.8d → none |
| 116 | **تأمین تجهیزات (Procurement)** | 2026-06-22 A | 94% → 100% | 46d → none |
| 125 | **تجهیزات جانبی مولد (Tool kit/Batteries)** | 2026-06-07 A | 90% → 100% | 59d → none |
| 126 | تأمین Tool Kit مخصوص کارخانه | 2026-04-28 A | 90% → 100% | 93d → none |
| 127 | تأمین باتری ها و شارژرها | 2026-06-07 A | 90% → 100% | 59d → none |
| 128 | تأمین متعلقات نصب و راه اندازی | 2026-06-07 A | 90% → 100% | 59d → none |
| 129 | **تأمین سیستم های مکانیکی** | 2026-05-30 A | 90% → 100% | 66d → none |
| 131 | ساخت و تأمین اجزای دودکش و سایلنسر | 2026-05-07 A | 90% → 100% | 0.1d → none |
| 132 | تأمین لوله و اتصالات گاز (Gas Train) | 2026-05-09 A | 10% → 100% | 0.85d → none |
| 135 | تامین عایق و رنگ | 2026-01-04 A | 10% → 100% | 191d → none |
| 136 | **تأمین پمپ ها و تجهیزات روغنکاری** | 2026-05-25 A | 95% → 100% | 0.9d → none |
| 139 | Feed Water | 2026-05-19 A | 90% → 100% | 4.5d → none |
| 140 | (Utility / Service / Cooling) | 2026-05-25 A | 90% → 100% | 0.9d → none |
| 141 | تأمین فن ها و دمپرهای تهویه سالن | 2026-05-30 A | 90% → 100% | 66d → none |
| 142 | **تأمین تجهیزات برقی و کنترل** | 2026-05-23 A | 91% → 100% | 72d → none |
| 143 | ساخت تابلوهای مصرف داخلی (Aux) | 2026-05-11 A | 90% → 100% | 2.7d → none |
| 144 | تأمین سوئیچگیر MV | 2026-05-14 A | 90% → 100% | 0.9d → none |
| 145 | خرید کابل های MV و LV | 2026-05-16 A | 90% → 100% | 0.9d → none |
| 146 | سیستم زمین (ارتینگ ثانویه) | 2026-05-17 A | 90% → 100% | 0.9d → none |
| 147 | تأمین سینی کابل و کاندوئیت ها | 2026-05-17 A | 90% → 100% | 0.9d → none |
| 148 | تأمین تجهیزات ابزاردقیق و مانیتورینگ | 2026-05-18 A | 90% → 100% | 3.8d → none |
| 149 | تامین تابلو gcp | 2026-05-18 A | 90% → 100% | 2.7d → none |
| 150 | تأمین Bulk Material | 2026-05-21 A | 90% → 100% | 73d → none |
| 151 | تأمین سیستم Gas Detection | 2026-05-23 A | 95% → 100% | 23.4d → none |
| 152 | **عملیات اجرایی (Construction)** | 2026-07-05 A | 95% → 100% | 0d → none |
| 153 | **عملیات سیویل و آماده سازی** | 2026-06-21 A | 99% → 100% | 12d → none |
| 162 | **عملیات تخریب و اصلاح سازه موجود** | 2026-06-20 A | 96% → 100% | 13.5d → none |
| 163 | بررسی وضعیت شلتر و سقف موجود | 2026-06-20 A | 90% → 100% | 13.5d → none |
| 164 | ایمن‌سازی و آماده‌سازی محل کار | 2026-05-26 A | 90% → 100% | 34d → none |
| 174 | **نصب تجهیزات مکانیکی** | 2026-06-25 A | 92% → 100% | 8d → none |
| 184 | **اجرای پایپینگ مربوط به پمپ‌ها** | 2026-06-23 A | 92% → 100% | 10d → none |
| 189 | **نصب مکانیکی پمپ‌ها** | 2026-06-03 A | 93% → 100% | 0.8d → none |
| 192 | نصب پمپ Feed Water | 2026-06-02 A | 85% → 100% | 0.85d → none |
| 193 | نصب سایر پمپ‌ها | 2026-06-03 A | 85% → 100% | 0.8d → none |
| 194 | **اجرای پایپینگ ورودی/خروجی پمپ‌ها** | 2026-06-09 A | 85% → 100% | 22d → none |
| 195 | suction پمپ‌ها oil | 2026-06-04 A | 80% → 100% | 0.8d → none |
| 196 | discharge پمپ‌ها oil | 2026-06-06 A | 80% → 100% | 1.9d → none |
| 197 | نصب ولوها و استرینرها | 2026-06-08 A | 90% → 100% | 0.9d → none |
| 198 | نصب ساپورت‌های لوله | 2026-06-09 A | 90% → 100% | 22d → none |
| 199 | **اجرای پایپینگ گاز و Gas Train** | 2026-05-11 A | 85% → 100% | 39.8d → none |
| 200 | آماده سازی برای اجرای پایپینگ گاز و Gas Train | 2026-05-10 A | 85% → 100% | 0.85d → none |
| 201 | اجرای نهایی و بازرسی اجرای پایپینگ گاز و Gas Train | 2026-05-11 A | 85% → 100% | 39.8d → none |
| 202 | **اجرای پایپینگ آب خنک کن** | 2026-06-22 A | 90% → 100% | 3.9d → none |
| 203 | آماده سازی برای اجرای پایپینگ آب خنک کن | 2026-06-21 A | 90% → 100% | 0.9d → none |
| 204 | اجرای نهایی و بازرسی اجرای پایپینگ آب خنک کن | 2026-06-22 A | 90% → 100% | 3.9d → none |
| 205 | **نصب سیستم های روغنکاری و مخازن** | 2026-06-01 A | 90% → 100% | 29d → none |
| 206 | آماده سازی برای نصب سیستم های روغنکاری و مخازن | 2026-05-31 A | 90% → 100% | 0.9d → none |
| 207 | اجرای نهایی و بازرسی نصب سیستم های روغنکاری و مخازن | 2026-06-01 A | 90% → 100% | 29d → none |
| 208 | **نصب تجهیزات تهویه و فن های سالن** | 2026-06-01 A | 90% → 100% | 29d → none |
| 209 | آماده سازی برای نصب تجهیزات تهویه و فن های سالن | 2026-05-31 A | 90% → 100% | 0.9d → none |
| 210 | اجرای نهایی و بازرسی نصب تجهیزات تهویه و فن های سالن | 2026-06-01 A | 90% → 100% | 29d → none |
| 211 | **عایق کاری لوله های داغ و اگزوز** | 2026-06-23 A | 90% → 100% | 0.9d → none |

| ID | Task | Start | Finish | Complete | Total float |
| --- | --- | --- | --- | --- | --- |
| 212 | آماده سازی برای عایق کاری لوله های داغ و اگزوز |  | 2026-06-22 A | 90% → 100% | 0.9d → none |
| 213 | اجرای نهایی و بازرسی عایق کاری لوله های داغ و اگزوز |  | 2026-06-23 A | 90% → 100% | 0.9d → none |
| 214 | **رنگ آمیزی و پوشش نهایی تجهیزات** |  | 2026-06-25 A | 90% → 100% | 0.8d → none |
| 215 | آماده سازی برای رنگ آمیزی و پوشش نهایی تجهیزات |  | 2026-06-24 A | 90% → 100% | 0.9d → none |
| 216 | اجرای نهایی و بازرسی رنگ آمیزی و پوشش نهایی تجهیزات |  | 2026-06-25 A | 90% → 100% | 0.8d → none |
| 217 | **اجرای سیستم های برقی** |  | 2026-07-05 A | 89% → 100% | 0d → none |
| 218 | **اجرای شبکه زمین و ارتینگ ثانویه** |  | 2026-06-28 A | 90% → 100% | 6d → none |
| 219 | آماده سازی برای اجرای شبکه زمین و ارتینگ ثانویه |  | 2026-06-27 A | 90% → 100% | 0.9d → none |
| 220 | اجرای نهایی و بازرسی اجرای شبکه زمین و ارتینگ ثانویه |  | 2026-06-28 A | 90% → 100% | 6d → none |
| 221 | **نصب سینی کابل و نردبان کابل** |  | 2026-06-28 A | 90% → 100% | 0.9d → none |
| 222 | آماده سازی برای نصب سینی کابل و نردبان کابل |  | 2026-06-27 A | 90% → 100% | 0.9d → none |
| 223 | اجرای نهایی و بازرسی نصب سینی کابل و نردبان کابل |  | 2026-06-28 A | 90% → 100% | 0.9d → none |
| 224 | **نصب تابلوهای فشار متوسط (MV)** |  | 2026-06-28 A | 90% → 100% | 6d → none |
| 225 | آماده سازی برای نصب تابلوهای فشار متوسط (MV) |  | 2026-06-27 A | 90% → 100% | 0.9d → none |
| 226 | اجرای نهایی و بازرسی نصب تابلوهای فشار متوسط (MV) |  | 2026-06-28 A | 90% → 100% | 6d → none |
| 227 | **نصب تابلوهای فشار ضعیف و مصرف داخلی** |  | 2026-06-28 A | 90% → 100% | 0.9d → none |
| 228 | آماده سازی برای نصب تابلوهای فشار ضعیف و مصرف داخلی |  | 2026-06-27 A | 90% → 100% | 0.9d → none |
| 229 | اجرای نهایی و بازرسی نصب تابلوهای فشار ضعیف و مصرف داخلی |  | 2026-06-28 A | 90% → 100% | 0.9d → none |
| 230 | **کابل کشی قدرت (MV/LV)** |  | 2026-07-02 A | 88% → 100% | 0.9d → none |
| 231 | آماده سازی برای کابل کشی قدرت (MV/LV) |  | 2026-06-29 A | 90% → 100% | 0.8d → none |
| 232 | اجرای نهایی و بازرسی کابل کشی قدرت (MV/LV) |  | 2026-06-30 A | 80% → 100% | 0.9d → none |
| 233 | آماده سازی برای کابل کشی aux |  | 2026-07-01 A | 90% → 100% | 0.9d → none |
| 234 | اجرای نهایی و بازرسی کابل کشی aux |  | 2026-07-02 A | 90% → 100% | 0.9d → none |
| 235 | **کابل کشی کنترل و ابزاردقیق** |  | 2026-06-30 A | 90% → 100% | 2.9d → none |
| 236 | آماده سازی برای کابل کشی کنترل و ابزاردقیق |  | 2026-06-29 A | 90% → 100% | 0.9d → none |
| 237 | اجرای نهایی و بازرسی کابل کشی کنترل و ابزاردقیق |  | 2026-06-30 A | 90% → 100% | 2.9d → none |
| 238 | **سربندی (Termination) کابل ها** |  | 2026-07-05 A | 90% → 100% | 0d → none |
| 239 | آماده سازی برای سربندی (Termination) کابل ها |  | 2026-07-04 A | 90% → 100% | 0.9d → none |
| 240 | اجرای نهایی و بازرسی سربندی (Termination) کابل ها |  | 2026-07-05 A | 90% → 100% | 0d → none |
| 241 | **نصب ابزاردقیق و کنترل** |  | 2026-06-27 A | 85% → 100% | 7d → none |
| 242 | **نصب تجهیزات مانیتورینگ موتور** |  | 2026-06-27 A | 90% → 100% | 7d → none |
| 243 | آماده سازی برای نصب تجهیزات مانیتورینگ موتور |  | 2026-06-27 A | 90% → 100% | 7d → none |
| 244 | اجرای نهایی و بازرسی نصب تجهیزات مانیتورینگ موتور |  | 2026-06-27 A | 90% → 100% | 7d → none |
| 245 | **نصب سنسورها و تجهیزات فیلد** |  | 2026-06-27 A | 90% → 100% | 7d → none |
| 246 | آماده سازی برای نصب سنسورها و تجهیزات فیلد |  | 2026-06-27 A | 90% → 100% | 7d → none |
| 247 | اجرای نهایی و بازرسی نصب سنسورها و تجهیزات فیلد |  | 2026-06-27 A | 90% → 100% | 7d → none |
| 248 | **نصب سیستم Gas Detection** |  | 2026-06-27 A | 80% → 100% | 7d → none |
| 249 | آماده سازی برای نصب سیستم Gas Detection |  | 2026-06-27 A | 80% → 100% | 7d → none |
| 250 | اجرای نهایی و بازرسی نصب سیستم Gas Detection |  | 2026-06-27 A | 80% → 100% | 7d → none |
| 251 | **نصب و پیکربندی سیستم کنترل مرکزی** |  | 2026-06-27 A | 80% → 100% | 7d → none |
| 252 | آماده سازی برای نصب و پیکربندی سیستم کنترل مرکزی |  | 2026-06-27 A | 80% → 100% | 7d → none |
| 253 | اجرای نهایی و بازرسی نصب و پیکربندی سیستم کنترل مرکزی |  | 2026-06-27 A | 80% → 100% | 7d → none |
| 254 | **تست و راه اندازی (Commissioning)** |  | 2026-07-11 A | 4% → 100% | 0d → none |
| 255 | **تست های پیش راه اندازی (Pre-Comm)** |  | 2026-07-09 A | 50% → 100% | 1d → none |
| 256 | چک‌لیست‌های نصب تجهیزات |  | 2026-07-09 A | 50% → 100% | 1d → none |
| 257 | تست عایقی و پیوستگی کابل ها |  | 2026-07-09 A | 50% → 100% | 0d → none |
| 258 | تمیزکاری و فلاشینگ سیستم‌ها |  | 2026-07-09 A | 50% → 100% | 1d → none |
| 259 | **تست ترانسفورماتور** | 2026-07-06 A | 2026-07-09 A | 0% → 100% | 1d → none |
| 260 | تست نسبت تبدیل (TTR Test) | 2026-07-06 A | 2026-07-09 A | 0% → 100% | 1d → none |
| 261 | تست عایقی (IR / Megger Test) | 2026-07-06 A | 2026-07-09 A | 0% → 100% | 1d → none |
| 262 | تست روغن ترانس (BDV & DGA) | 2026-07-06 A | 2026-07-09 A | 0% → 100% | 1d → none |
| 263 | تست عملکرد بی‌بار (No Load Test) | 2026-07-06 A | 2026-07-09 A | 0% → 100% | 1d → none |
| 264 | تست تحت بار (Load Test) | 2026-07-06 A | 2026-07-09 A | 0% → 100% | 1d → none |
| 265 | **تست ژنراتور / مولد** | 2026-07-06 A | 2026-07-09 A | 0% → 100% | 1d → none |
| 266 | تست عایقی ژنراتور | 2026-07-06 A | 2026-07-09 A | 0% → 100% | 1d → none |
| 267 | تست مدار تحریک | 2026-07-06 A | 2026-07-09 A | 0% → 100% | 1d → none |
| 268 | تست سنکرونیزاسیون | 2026-07-06 A | 2026-07-09 A | 0% → 100% | 1d → none |
| 269 | تست بی‌بار | 2026-07-06 A | 2026-07-09 A | 0% → 100% | 1d → none |
| 270 | تست تحت بار کامل (Full Load Test) | 2026-07-06 A | 2026-07-09 A | 0% → 100% | 1d → none |
| 271 | تست حفاظت‌ها (Protection Test) | 2026-07-06 A | 2026-07-09 A | 0% → 100% | 1d → none |
| 272 | **تست رادیاتور و سیستم خنک‌کاری** | 2026-07-06 A | 2026-07-09 A | 0% → 100% | 1d → none |
| 273 | تست فشار (Pressure Test) | 2026-07-06 A | 2026-07-09 A | 0% → 100% | 1d → none |
| 274 | تست نشتی (Leak Test) | 2026-07-06 A | 2026-07-09 A | 0% → 100% | 1d → none |
| 275 | تست عملکرد فن‌ها | 2026-07-06 A | 2026-07-09 A | 0% → 100% | 1d → none |
| 276 | تست گردش سیال خنک‌کننده | 2026-07-06 A | 2026-07-09 A | 0% → 100% | 1d → none |
| 277 | تست عملکرد در بار نامی | 2026-07-06 A | 2026-07-09 A | 0% → 100% | 1d → none |
| 278 | **تست سوئیچگیر (MV / LV Switchgear)** | 2026-07-06 A | 2026-07-09 A | 0% → 100% | 1d → none |
| 279 | تست عایقی (IR Test) | 2026-07-06 A | 2026-07-09 A | 0% → 100% | 1d → none |
| 280 | تست عملکرد بریکرها | 2026-07-06 A | 2026-07-09 A | 0% → 100% | 1d → none |
| 281 | تست اینترلاک‌ها | 2026-07-06 A | 2026-07-09 A | 0% → 100% | 1d → none |

| ID | Task | Start | Finish | Complete | Total float |
| --- | --- | --- | --- | --- | --- |
| 282 | تست رله‌های حفاظتی | 2026-07-06 A | 2026-07-09 A | 0% → 100% | 1d → none |
| 283 | تست قطع و وصل تحت بار | 2026-07-06 A | 2026-07-09 A | 0% → 100% | 1d → none |
| 284 | تست هماهنگی حفاظتی | 2026-07-06 A | 2026-07-09 A | 0% → 100% | 1d → none |
| 285 | تست تابلو gcp و aux | 2026-07-06 A | 2026-07-09 A | 0% → 100% | 1d → none |
| 286 | **تست سیستم کولینگ (Cooling System) سالن موتور** | 2026-07-06 A | 2026-07-09 A | 0% → 100% | 0d → none |
| 287 | تست پمپ‌های سیستم خنک‌کاری | 2026-07-06 A | 2026-07-09 A | 0% → 100% | 1d → none |
| 288 | تست مدار لوله‌کشی خنک‌کاری | 2026-07-06 A | 2026-07-09 A | 0% → 100% | 0d → none |
| 289 | تست عملکرد مبدل‌های حرارتی | 2026-07-06 A | 2026-07-09 A | 0% → 100% | 1d → none |
| 290 | تست دبی و فشار سیستم | 2026-07-06 A | 2026-07-09 A | 0% → 100% | 1d → none |
| 291 | تست عملکرد در شرایط عملیاتی | 2026-07-06 A | 2026-07-09 A | 0% → 100% | 1d → none |
| 292 | **تست‌های یکپارچه (Integrated Tests)** | 2026-07-06 A | 2026-07-09 A | 0% → 100% | 1d → none |
| 293 | تست بدون بار کل واحد (No Load Test Run) | 2026-07-06 A | 2026-07-09 A | 0% → 100% | 1d → none |
| 294 | تست سنکرون کل سیستم | 2026-07-06 A | 2026-07-09 A | 0% → 100% | 1d → none |
| 295 | تست Load Acceptance | 2026-07-06 A | 2026-07-09 A | 0% → 100% | 1d → none |
| 296 | تست Trip و Emergency Shutdown | 2026-07-06 A | 2026-07-09 A | 0% → 100% | 1d → none |
| 297 | تست عملکرد سیستم‌های کمکی | 2026-07-06 A | 2026-07-09 A | 0% → 100% | 1d → none |
| 298 | **Cold Loop Test ابزاردقیق** | 2026-07-06 A | 2026-07-06 A | 0% → 100% | 4d → none |
| 299 | آماده سازی برای Cold Loop Test ابزاردقیق | 2026-07-06 A | 2026-07-06 A | 0% → 100% | 4d → none |
| 300 | اجرای نهایی و بازرسی Cold Loop Test ابزاردقیق | 2026-07-06 A | 2026-07-06 A | 0% → 100% | 4d → none |
| 301 | **راه اندازی (Commissioning)** | 2026-07-11 A | 2026-07-11 A | 0% → 100% | 0d → none |
| 302 | برق دار کردن تابلوهای داخلی | 2026-07-11 A | 2026-07-11 A | 0% → 100% | 0d → none |
| 303 | تست عملکردی سیستم سوخت رسانی | 2026-07-11 A | 2026-07-11 A | 0% → 100% | 0d → none |
| 304 | استارت اولیه مولد بدون بار | 2026-07-11 A | 2026-07-11 A | 0% → 100% | 0d → none |
| 305 | تست پارالل و سنکرون سازی | 2026-07-11 A | 2026-07-11 A | 0% → 100% | 0d → none |
| 306 | تست عملکردی زیر بار (Load Test) | 2026-07-11 A | 2026-07-11 A | 0% → 100% | 0d → none |
| 307 | تست نهایی سیستم Gas Detection | 2026-07-11 A | 2026-07-11 A | 0% → 100% | 0d → none |
| 308 | **تحویل و بهره برداری (Close-out)** | 2026-07-12 A | 2026-08-15 A | 0% → 100% | 0d → none |
| 309 | **بهره برداری آزمایشی** | 2026-07-12 A | 2026-07-30 A | 0% → 100% | 0d → none |
| 310 | دوره 72 ساعته تست مداوم | 2026-07-12 A | 2026-07-12 A | 0% → 100% | 0d → none |
| 311 | رفع نواقص احتمالی (Punch List) | 2026-07-13 A | 2026-07-30 A | 0% → 100% | 0d → none |
| 312 | **مستندات و تحویل** | 2026-08-01 A | 2026-08-15 A | 0% → 100% | 0d → none |
| 313 | تهیه نقشه های As-Built | 2026-08-01 A | 2026-08-02 A | 0% → 100% | 0d → none |
| 314 | آموزش تیم بهره بردار کارفرما | 2026-08-03 A | 2026-08-05 A | 0% → 100% | 0d → none |
| 315 | تحویل موقت (PAC) | 2026-08-06 A | 2026-08-13 A | 0% → 100% | 0d → none |
| 316 | شروع دوره بهره برداری (Operation) | 2026-08-15 A | 2026-08-15 A | 0% → 100% | 0d → none |
| 317 | پایان | 2026-08-15 A | 2026-08-15 A | 0% → 100% | 0d → none |

## Version 3 (data date 2026-07-13, saved 2026-07-13, file plan.mpp)

Last finish stays 2026-08-15. Complete tasks 229 → 223.

Changed:

| ID | Task | Start | Finish | Complete | Total float |
| --- | --- | --- | --- | --- | --- |
| 1 | **پروژه احداث نیروگاه گازسوز 2000 کیلووات (CAT CG170)** |  | 2026-08-15 A → 2026-08-15 | 100% → 95% | none → 0d |
| 308 | **تحویل و بهره برداری (Close-out)** |  | 2026-08-15 A → 2026-08-15 | 100% → 7% | none → 0d |
| 309 | **بهره برداری آزمایشی** |  | 2026-07-30 A → 2026-07-30 | 100% → 12% | none → 0d |
| 311 | رفع نواقص احتمالی (Punch List) |  | 2026-07-30 A → 2026-07-30 | 100% → 6% | none → 0d |
| 312 | **مستندات و تحویل** | 2026-08-01 A → 2026-08-01 | 2026-08-15 A → 2026-08-15 | 100% → 0% | none → 0d |
| 313 | تهیه نقشه های As-Built | 2026-08-01 A → 2026-08-01 | 2026-08-02 A → 2026-08-02 | 100% → 0% | none → 0d |
| 314 | آموزش تیم بهره بردار کارفرما | 2026-08-03 A → 2026-08-03 | 2026-08-05 A → 2026-08-05 | 100% → 0% | none → 0d |
| 315 | تحویل موقت (PAC) | 2026-08-06 A → 2026-08-06 | 2026-08-13 A → 2026-08-13 | 100% → 0% | none → 0d |
| 316 | شروع دوره بهره برداری (Operation) | 2026-08-15 A → 2026-08-15 | 2026-08-15 A → 2026-08-15 | 100% → 0% | none → 0d |
| 317 | پایان | 2026-08-15 A → 2026-08-15 | 2026-08-15 A → 2026-08-15 | 100% → 0% | none → 0d |
